# ClassicProject

Schedule from MS Project, 2013-05-01 to 2013-06-14.
VOLKSWAGEN GROUP

## Calendars

- Standard: Mon-Fri 08:00-12:00, 13:00-17:00; Sat-Sun off.

## Schedule

| ID | WBS | Task | Duration | Start | Finish | Predecessors | Total slack |
| --- | --- | --- | --- | --- | --- | --- | --- |
| 1 | 1 | **Stage Test** | 11d | 2013-05-01 | 2013-05-15 |  | 0d |
| 2 | 1.1 | Aufbau Datenbank | 4d | 2013-05-01 | 2013-05-06 |  | 0d |
| 3 | 1.2 | Aufbau Linux Server Middleware | 3d | 2013-05-07 | 2013-05-09 | 2 | 0d |
| 4 | 1.3 | Aufbau Webseal | 2d | 2013-05-10 | 2013-05-13 | 3 | 24d |
| 5 | 1.4 | Installation WAS | 4d | 2013-05-10 | 2013-05-15 | 3 | 0d |
| 6 | 2 | **Stage QS** | 11d | 2013-05-16 | 2013-05-30 |  | 0d |
| 7 | 2.1 | Aufbau Datenbank | 4d | 2013-05-16 | 2013-05-21 | 5 | 0d |
| 8 | 2.2 | Aufbau Linux Server Middleware | 3d | 2013-05-22 | 2013-05-24 | 7 | 0d |
| 9 | 2.3 | Aufbau Webseal | 2d | 2013-05-27 | 2013-05-28 | 8 | 13d |
| 10 | 2.4 | Installation WAS | 4d | 2013-05-27 | 2013-05-30 | 8 | 0d |
| 11 | 3 | **Stage Prod** | 11d | 2013-05-31 | 2013-06-14 | 10 | 0d |
| 12 | 3.1 | Aufbau Datenbank | 4d | 2013-05-31 | 2013-06-05 |  | 0d |
| 13 | 3.2 | Aufbau Linux Server Middleware | 3d | 2013-06-06 | 2013-06-10 | 12 | 0d |
| 14 | 3.3 | Aufbau Webseal | 2d | 2013-06-11 | 2013-06-12 | 13 | 2d |
| 15 | 3.4 | Installation WAS | 4d | 2013-06-11 | 2013-06-14 | 13 | 0d |
